# CPF2022

Schedule from MS Project, 2022-01-24 to 2022-07-30.
MBARI

## Calendars

- Standard: Mon-Fri 08:00-12:00, 13:00-17:00; Sat-Sun off.

## Resources

| Resource |
| --- |
| Chad |
| Eric |
| Gene |
| All |
| Intern |
| Paul |
| Roman |
| Aaron |
| Jose |

## Schedule

| ID | WBS | Task | Type | Duration | Start | Finish | Predecessors | Total slack | Free slack | Resources | Work |
| --- | --- | --- | --- | --- | --- | --- | --- | --- | --- | --- | --- |
| 1 | 1 | CPF 2022 | manual | 1d? | 2022-01-24 | 2022-01-24 |  |  |  |  |  |
| 2 | 2 | Solve pump against pressure issue |  | 10d | 2022-01-24 | 2022-02-04 |  | 109d | 0d | Gene | 80h |
| 3 | 3 | build hydraulic test bench |  | 1d | 2022-01-24 | 2022-01-24 |  | 134d |  | Paul; Roman; Aaron; Gene | 32h |
| 5 | 4 | **CPF001** |  | 20d | 2022-01-24 | 2022-02-18 |  | 87d | 0d | Eric | 240h |
| 6 | 4.1 | Finish build |  | 5d | 2022-01-24 | 2022-01-28 |  | 87d | 0d |  |  |
| 7 | 4.2 | pre-oil commissioning |  | 5d | 2022-01-31 | 2022-02-04 | 6 | 87d | 0d |  |  |
| 8 | 4.3 | finish hydraulics |  | 5d | 2022-01-24 | 2022-01-28 |  | 102d |  | Gene; Paul | 80h |
| 9 | 4.4 | oil fill |  | 5d | 2022-01-24 | 2022-01-28 |  | 102d |  |  |  |
| 10 | 4.5 | post-oil commissioning |  | 5d | 2022-02-07 | 2022-02-11 | 7 | 87d | 0d |  |  |
| 11 | 4.6 | tank test |  | 5d | 2022-02-14 | 2022-02-18 | 10 | 87d |  |  |  |
| 12 | 4.7 | sea test |  | 5d | 2022-01-24 | 2022-01-28 |  | 102d |  |  |  |
| 14 | 5 | **CPF002** |  | 25d | 2022-02-21 | 2022-03-25 | 5 | 87d | 47d | Eric | 280h |
| 15 | 5.1 | install ext bellows |  | 5d | 2022-02-21 | 2022-02-25 |  | 87d | 0d | Gene; Paul | 80h |
| 16 | 5.2 | oil fil |  | 5d | 2022-02-28 | 2022-03-04 | 15 | 87d | 0d |  |  |
| 17 | 5.3 | final commissioning |  | 5d | 2022-03-07 | 2022-03-11 | 16 | 87d | 0d |  |  |
| 18 | 5.4 | tank test |  | 5d | 2022-03-14 | 2022-03-18 | 17 | 87d | 0d |  |  |
| 19 | 5.5 | sea test |  | 5d | 2022-03-21 | 2022-03-25 | 18 | 87d |  |  |  |
| 21 | 6 | **CPF003** |  | 16d | 2022-02-07 | 2022-02-28 |  | 109d |  |  |  |
| 22 | 6.1 | Integrate PAP fix |  | 1d | 2022-02-07 | 2022-02-07 | 2 | 109d | 0d |  |  |
| 23 | 6.2 | tank test |  | 5d | 2022-02-08 | 2022-02-14 | 22 | 109d | 0d |  |  |
| 24 | 6.3 | sea test |  | 10d | 2022-02-15 | 2022-02-28 | 23 | 109d |  |  |  |
| 26 | 7 | Upwelling experiment | milestone, manual | 0d | 2022-06-01 | 2022-06-01 | 5, 14 |  |  | All |  |
| 28 | 8 | **LI Primary LHE** |  | 62d? | 2022-01-24 | 2022-04-19 |  | 38d | 20d | Chad | 872h |
| 29 | 8.1 | Get design into layout |  | 5d | 2022-01-24 | 2022-01-28 |  | 75d | 0d |  |  |
| 30 | 8.2 | layout |  | 5d | 2022-01-31 | 2022-02-04 | 29 | 75d | 0d | Chad; Jose | 80h |
| 31 | 8.3 | order N PWBs |  | 5d | 2022-02-07 | 2022-02-11 | 30 | 75d | 0d | Jose | 40h |
| 32 | 8.4 | Build 1 CCA |  | 5d | 2022-02-14 | 2022-02-18 | 31 | 75d | 0d | Jose | 40h |
| 33 | 8.5 | Test 1 CCA |  | 5d | 2022-02-21 | 2022-02-25 | 32 | 75d | 57d | Chad | 40h |
| 34 | 8.6 | Integrate with battery pack |  | 5d | 2022-04-13 | 2022-04-19 | 43 | 38d |  | Gene; Chad | 80h |
| 35 | 8.7 | Build remaing LHEs (maybe 6?) |  | 10d | 2022-01-24 | 2022-02-04 |  | 90d |  | Jose | 80h |
| 36 | 8.8 | test remaining LHEs |  | 1d | 2022-01-24 | 2022-01-24 |  | 99d |  | Chad | 8h |
| 37 | 8.9 | Get all of Ed's notes (e.g. LHE P2 checkout) on Project Library |  | 1d? | 2022-01-24 | 2022-01-24 |  | 99d |  | Chad | 8h |

| ID | WBS | Task | Type | Duration | Start | Finish | Predecessors | Total slack | Free slack | Constraint | Resources | Work |
| --- | --- | --- | --- | --- | --- | --- | --- | --- | --- | --- | --- | --- |
| 39 | 9 | **Li primary battery packs** |  | 102d | 2022-01-24 | 2022-06-14 |  | 33d |  |  | Gene | 984h |
| 40 | 9.1 | Finalize design |  | 10d | 2022-01-24 | 2022-02-04 |  | 33d | 0d |  |  |  |
| 41 | 9.2 | Clear with BSC |  | 1d | 2022-02-07 | 2022-02-07 | 40 | 33d | 0d |  | Chad | 8h |
| 42 | 9.3 | place PO |  | 1d | 2022-02-08 | 2022-02-08 | 41 | 33d | 0d |  |  |  |
| 43 | 9.4 | test first article |  | 5d | 2022-04-06 | 2022-04-12 | 42FS+40d | 33d | 0d |  | Chad; Gene | 80h |
| 44 | 9.5 | test remaining parts |  | 5d | 2022-06-08 | 2022-06-14 | 43FS+40d | 33d |  |  | Chad; Gene | 80h |
| 46 | 10 | **New DC/DC Converter Board** |  | 3d | 2022-06-01 | 2022-06-03 | 26 | 40d |  |  |  |  |
| 47 | 10.1 | Design it |  | 1d | 2022-06-01 | 2022-06-01 |  | 40d | 0d |  |  |  |
| 48 | 10.2 | Build it |  | 1d | 2022-06-02 | 2022-06-02 | 47 | 40d | 0d |  |  |  |
| 49 | 10.3 | Test it |  | 1d | 2022-06-03 | 2022-06-03 | 48 | 40d |  |  |  |  |
| 51 | 11 | **Build TTP** |  | 35d | 2022-05-18 | 2022-07-05 | 28 | 18d |  | start no earlier than 2022-05-18 | Intern | 280h |
| 52 | 11.1 | Finish build |  | 5d | 2022-05-18 | 2022-05-24 | 33, 43 | 18d | 0d |  |  |  |
| 53 | 11.2 | pre-oil commissioning |  | 5d | 2022-05-25 | 2022-05-31 | 52 | 18d | 0d |  |  |  |
| 54 | 11.3 | install ext bellows |  | 5d | 2022-06-01 | 2022-06-07 | 53 | 18d | 0d |  |  |  |
| 55 | 11.4 | oil fill |  | 5d | 2022-06-08 | 2022-06-14 | 54 | 18d | 0d |  |  |  |
| 56 | 11.5 | post-oil commissioning |  | 5d | 2022-06-15 | 2022-06-21 | 53, 55 | 18d | 0d |  |  |  |
| 57 | 11.6 | tank test |  | 5d | 2022-06-22 | 2022-06-28 | 56 | 18d | 0d |  |  |  |
| 58 | 11.7 | at-sea test |  | 5d | 2022-06-29 | 2022-07-05 | 57 | 18d |  |  |  |  |
| 60 | 12 | Ocean imaging cruise | manual | 7d | 2022-02-17 | 2022-02-25 |  |  |  |  | Eric | 56h |
| 61 | 13 | Eric Vacation | manual | 22d | 2022-07-01 | 2022-07-30 |  |  |  |  | Eric | 176h |
| 62 | 14 | Chad Vacation | manual | 13d | 2022-05-22 | 2022-06-07 |  |  |  |  |  |  |
