# CPF2022_V2

Schedule from MS Project, 2022-01-03 to 2023-09-22.
MBARI

## Calendars

- Standard: Mon-Fri 08:00-12:00, 13:00-17:00; Sat-Sun off.

## Resources

| Resource |
| --- |
| Eric |
| Chad |
| Gene |
| Roman |
| James |
| Gene (personal time) |
| Shop |

## Schedule

| ID | WBS | Task | Type | Duration | Start | Finish | Predecessors | Total slack | Free slack | Constraint | Resources | Work |
| --- | --- | --- | --- | --- | --- | --- | --- | --- | --- | --- | --- | --- |
| 1 | 1 | **Upwelling pilot experiment** |  | 290d? | 2022-01-03 | 2023-02-10 |  | 0d |  |  |  | 240h |
| 2 | 1.1 | 1 CPF | manual | 84d | 2022-01-03 | 2022-04-28 |  |  |  |  |  |  |
| 3 | 1.2 | 2X CPF |  | 10d? | 2023-01-02 | 2023-01-13 | 18, 9 | 0d |  |  | Gene | 80h |
| 4 | 1.3 | 3X CPF |  | 20d? | 2023-01-16 | 2023-02-10 | 18, 19, 3 | 0d |  |  | Gene | 160h |
| 5 | 2 | 3X CPF upwelling experiment #1 |  | 20d | 2023-02-13 | 2023-03-10 | 4 | 0d |  |  | Gene | 160h |
| 6 | 3 | 3X CPF upwelling experiment #2 |  | 20d? | 2023-08-28 | 2023-09-22 | 5FS+120d, 10, 15 | 0d |  |  | Gene | 160h |
| 8 | 4 | **Software** |  | 315d | 2022-01-03 | 2023-03-17 |  | 0d |  |  |  | 150h |
| 9 | 4.1 | Finish sleep mode | manual | 260d | 2022-01-03 | 2022-12-30 |  |  |  |  | Eric | 100h |
| 10 | 4.2 | Finish Rudics | manual | 5d | 2023-03-13 | 2023-03-17 | 5 |  |  |  | Eric | 50h |
| 12 | 5 | **Electrical** |  | 315d | 2022-01-03 | 2023-03-17 |  | 135d |  |  |  | 330h |
| 13 | 5.1 | Finish Li Primary battery pack design |  | 250d | 2022-01-03 | 2022-12-16 |  | 78.75d | 0d |  | Chad [10%] | 200h |
| 14 | 5.2 | Integrate in TTP |  | 6.25d | 2022-12-19 | 2022-12-27 | 13 | 78.75d |  |  | Chad | 50h |
| 15 | 5.3 | Integrate in 3X CPFs | manual | 5d | 2023-03-13 | 2023-03-17 | 5 |  |  |  | Chad; Gene | 80h |
| 17 | 6 | **Manufacturing** |  | 83.33d | 2022-09-01 | 2022-12-27 |  | 13.67d |  |  |  | 200h |
| 18 | 6.1 | Finish CPF1 |  | 33.33d | 2022-09-01 | 2022-10-18 |  | 13.67d | 0d | start no earlier than 2022-09-01 | Gene [15%]; Roman [15%] | 80h |
| 19 | 6.2 | Finish CPF2 |  | 50d | 2022-10-18 | 2022-12-27 | 18 | 13.67d |  |  | Gene [15%]; Roman [15%] | 120h |
| 21 | 7 | **New Controller** |  | 271d | 2022-01-03 | 2023-01-16 |  | 0d |  |  |  | 50h |
| 22 | 7.1 | Finish layout | manual | 194d | 2022-01-03 | 2022-09-29 |  |  |  |  | James; Gene (personal time) | 10h |
| 23 | 7.2 | Build | manual | 77d | 2022-09-30 | 2023-01-16 | 22 |  |  |  | James | 40h |
| 24 | 7.3 | test and integrate in TTP | milestone, manual | 0d | 2022-01-03 | 2022-01-03 |  |  |  |  | Gene |  |
| 26 | 8 | **Test Tank prototype** |  | 162d | 2022-09-01 | 2023-04-14 |  | 0d |  |  |  | 140.9h |
| 27 | 8.1 | Design interface plates | manual | 22d | 2022-09-01 | 2022-09-30 |  |  |  |  | Roman | 0.9h |
| 28 | 8.2 | Manufacturing |  | 18.75d | 2022-10-03 | 2022-10-27 | 27 | 71.25d | 0d |  | Shop [40%] | 60h |
| 29 | 8.3 | Build |  | 25d | 2022-10-27 | 2022-12-01 | 28 | 71.25d |  |  | Roman [20%] | 40h |
| 30 | 8.4 | Test |  | 25d | 2023-03-13 | 2023-04-14 | 29, 5 | 115d |  |  | Gene [10%]; Eric [10%] | 40h |
