# Schedule2018

Schedule from MS Project, 2018-01-04 to 2018-08-02, A marks actual dates.
MBARI

## Calendars

- Standard: Mon-Fri 08:00-12:00, 13:00-17:00; Sat-Sun off.

## Schedule

| ID | WBS | Task | Type | Duration | Start | Finish | Predecessors | Complete | Remaining | Total slack | Free slack |
| --- | --- | --- | --- | --- | --- | --- | --- | --- | --- | --- | --- |
| 1 | 1 | **Commision SN002** |  | 50d? | 2018-01-10 A | 2018-03-20 |  | 5% | 47.54d? | 97d |  |
| 2 | 1.1 | Run pump performance tests |  | 3d | 2018-01-10 A | 2018-01-12 A |  | 100% |  |  |  |
| 3 | 1.2 | **Build 3X motorized valves** |  | 6d? | 2018-01-10 | 2018-01-17 |  |  |  | 141d |  |
| 4 | 1.2.1 | All parts in house |  | 1d? | 2018-01-10 | 2018-01-10 |  |  |  | 141d | 0d |
| 5 | 1.2.2 | Build valves |  | 5d | 2018-01-11 | 2018-01-17 | 4 |  |  | 141d |  |
| 6 | 1.3 | Wire top half |  | 7d | 2018-01-10 | 2018-01-18 |  |  |  | 0d |  |
| 7 | 1.4 | Wire bottom half |  | 7d | 2018-01-19 | 2018-01-29 | 6 |  |  | 0d |  |
| 8 | 1.5 | Make sure CPF-3 software works like old SW |  | 10d | 2018-01-30 | 2018-02-12 | 7 |  |  | 0d |  |
| 9 | 1.6 | Fill external bladder |  | 1d | 2018-02-13 | 2018-02-13 | 8 |  |  | 97d | 0d |
| 10 | 1.7 | build up 2nd tube cover |  | 2d | 2018-01-10 | 2018-01-11 |  |  |  | 145d |  |
| 11 | 1.8 | bench and tank test |  | 5d | 2018-02-14 | 2018-02-20 | 9 |  |  | 97d | 0d |
| 12 | 1.9 | Calibrate sensors | manual | 5d | 2018-02-21 | 2018-02-27 | 11 |  |  |  |  |
| 13 | 1.10 | Sea test |  | 15d | 2018-02-28 | 2018-03-20 | 12 |  |  | 97d |  |
| 15 | 2 | **Commision SN001 and SN003** |  | 97d? | 2018-01-10 | 2018-05-24 |  |  |  | 24d |  |
| 16 | 2.1 | Submit drawings to shop (including parts for TTP) |  | 1d | 2018-02-13 | 2018-02-13 | 8 |  |  | 0d |  |
| 17 | 2.2 | Order remaining parts (including parts for TTP) |  | 1d | 2018-02-13 | 2018-02-13 | 8 |  |  | 122d |  |
| 18 | 2.3 | All parts in house | milestone | 0d | 2018-04-10 | 2018-04-10 | 16FS+40d |  |  | 0d |  |
| 19 | 2.4 | Build and wire SN002 |  | 8d | 2018-04-11 | 2018-04-20 | 18 |  |  | 0d |  |
| 20 | 2.5 | Build and wire SN003 |  | 8d | 2018-04-23 | 2018-05-02 | 19 |  |  | 0d |  |
| 21 | 2.6 | Bench and tank test |  | 5d | 2018-05-03 | 2018-05-09 | 20 |  |  | 0d |  |
| 22 | 2.7 | Calibrate sensors | manual | 1d? | 2018-05-10 | 2018-05-10 | 21 |  |  |  |  |
| 23 | 2.8 | Sea test |  | 10d | 2018-05-11 | 2018-05-24 | 22 |  |  | 0d |  |
| 25 | 2.9 | **Software-ish** |  | 34d? | 2018-01-10 | 2018-02-26 |  |  |  | 24d |  |
| 26 | 2.9.1 | Review science log file format | manual | 4d | 2018-02-13 | 2018-02-16 | 8 |  |  |  |  |
| 27 | 2.9.2 | Develop power management approach |  | 10d | 2018-02-13 | 2018-02-26 | 8 |  |  | 63d |  |
| 28 | 2.9.3 | Review error recovery scheme |  | 10d | 2018-02-13 | 2018-02-26 | 8 |  |  | 63d |  |
| 29 | 2.9.4 | Refine/develop mission management software |  | 10d | 2018-02-13 | 2018-02-26 | 8 |  |  | 113d |  |
| 30 | 2.9.5 | Inertial current meter |  | 1d? | 2018-01-10 | 2018-01-10 |  |  |  | 146d |  |
| 32 | 3 | Pre-run science mission |  | 20d | 2018-05-25 | 2018-06-21 | 23, 27, 28 |  |  | 0d |  |
| 33 | 4 | Science Mission |  | 30d | 2018-06-22 | 2018-08-02 | 32 |  |  | 0d |  |
| 35 | 5 | Design, build, test new battery management board |  | 1d? | 2018-01-10 | 2018-01-10 |  |  |  | 146d |  |
| 36 | 6 | Design, build, test new Digital IO board |  | 1d | 2018-01-10 | 2018-01-10 |  |  |  | 146d |  |

| ID | WBS | Task | Duration | Start | Finish | Predecessors | Total slack | Free slack |
| --- | --- | --- | --- | --- | --- | --- | --- | --- |
| 38 | 7 | **Commission TTP** | 13d | 2018-04-11 | 2018-04-27 |  | 69d |  |
| 39 | 7.1 | Build and wire TTP | 8d | 2018-04-11 | 2018-04-20 | 18 | 69d | 0d |
| 40 | 7.2 | Bench and tank test | 5d | 2018-04-23 | 2018-04-27 | 39 | 69d |  |
| 42 | 8 | **Issues** | 1d? | 2018-01-10 | 2018-01-10 |  | 146d |  |
| 43 | 8.1 | Power for Twitter | 1d? | 2018-01-10 | 2018-01-10 |  | 146d |  |
| 44 | 8.2 | RUDICS throughput | 1d? | 2018-01-10 | 2018-01-10 |  | 146d |  |
| 46 | 9 | **Risks** | 5d? | 2018-01-04 | 2018-01-10 |  | 0d |  |
| 47 | 9.1 | Power management | 1d? | 2018-01-10 | 2018-01-10 |  | 146d |  |
| 48 | 9.2 | Array Navigation | 1d? | 2018-01-10 | 2018-01-10 |  | 146d |  |
| 49 | 9.3 | Biofouling | 1d? | 2018-01-10 | 2018-01-10 |  | 146d |  |
| 50 | 9.4 | Electrical noise in the housing | 1d? | 2018-01-10 | 2018-01-10 |  | 146d |  |
| 51 | 9.5 | Battery Packs | 1d? | 2018-01-10 | 2018-01-10 |  | 146d |  |
