# Schedule2019Aug20

Schedule from MS Project, 2019-08-20 to 2019-11-25, A marks actual dates.
MBARI

## Calendars

- Standard: Mon-Fri 08:00-12:00, 13:00-17:00; Sat-Sun off.

## Resources

| Resource |
| --- |
| Ed |
| Eric |
| Jose |
| Chad |
| Gene |
| Paul |
| Tom |
| Gene Eric |

## Schedule

| ID | WBS | Task | Duration | Start | Finish | Predecessors | Complete | Remaining | Baseline start | Baseline finish | Baseline duration | Total slack | Free slack | Constraint | Resources | Work | Actual work |
| --- | --- | --- | --- | --- | --- | --- | --- | --- | --- | --- | --- | --- | --- | --- | --- | --- | --- |
| 1 | 1 | **eTech Tasks** | 42d? | 2019-08-22 A | 2019-10-18 |  | 52% | 20.24d? | 2019-08-22 | 2019-10-18 | 42d? | 25.67d |  |  |  | 360h | 106.8h |
| 2 | 1.1 | Build 3rd LHE | 19d | 2019-09-24 A | 2019-10-18 A | 14 | 100% |  | 2019-09-24 | 2019-10-18 | 19d |  |  |  | Jose | 32h | 32h |
| 3 | 1.2 | Build 3rd and 4th ISB | 16d | 2019-08-30 A | 2019-09-20 A | 21 | 100% |  | 2019-08-30 | 2019-09-20 | 16d |  |  |  | Jose | 24h | 24h |
| 4 | 1.3 | Ed's wire harnesses | 22d? | 2019-08-22 A | 2019-09-20 |  | 50% | 11d? | 2019-08-22 | 2019-09-20 | 22d? | 1.4d | 0d | finish no earlier than 2019-09-20 | Jose | 24h | 12h |
| 5 | 1.4 | Chad's wire harnesses | 22d? | 2019-08-22 A | 2019-09-20 |  | 25% | 16.5d? | 2019-08-22 | 2019-09-20 | 22d? | 2.5d | 0d | finish no earlier than 2019-09-20 | Jose | 24h | 6h |
| 6 | 1.5 | Build 4th and 5th LHE | 2d | 2019-09-30 A | 2019-10-01 | 15 | 20% | 1.6d | 2019-09-30 | 2019-10-01 | 2d | 35.67d | 5d | finish no earlier than 2019-09-30 | Jose | 64h | 12.8h |
| 7 | 1.6 | Build 5th ISB | 6d | 2019-10-01 | 2019-10-08 | 24 |  |  | 2019-10-01 | 2019-10-08 | 6d | 30.67d | 0d |  | Jose | 48h |  |
| 8 | 1.7 | Build 6th motherboard | 3d | 2019-10-09 | 2019-10-11 | 6, 7 |  |  | 2019-10-09 | 2019-10-11 | 3d | 30.67d |  |  | Jose | 24h |  |
| 9 | 1.8 | First BT board | 5d | 2019-09-23 A | 2019-09-27 | 3, 4, 5 | 50% | 2.5d | 2019-09-23 | 2019-09-27 | 5d | 30.67d | 0d |  | Jose | 40h | 20h |
| 10 | 1.9 | 2-5 BT boards | 10d | 2019-09-30 | 2019-10-11 | 9 |  |  | 2019-09-30 | 2019-10-11 | 10d | 30.67d |  |  | Jose | 80h |  |
| 12 | 2 | **Finish LHE CCA** | 46.67d? | 2019-08-20 A | 2019-10-23 |  | 70% | 13.82d? | 2019-08-20 | 2019-10-23 | 46.67d? | 0d |  |  |  | 238.4h | 149.6h |
| 13 | 2.1 | Ed's bench testing | 21d | 2019-08-20 A | 2019-09-17 A |  | 100% |  | 2019-08-20 | 2019-09-17 | 21d |  |  |  | Ed [80%] | 134.4h | 134.4h |
| 14 | 2.2 | Eric's software testing | 4d | 2019-09-18 A | 2019-09-23 | 13 | 75% | 1d | 2019-09-18 | 2019-09-23 | 4d | 0.4d | 0d |  | Eric [50%] | 16h | 12h |
| 15 | 2.3 | Integrate and test in SN003 | 4d | 2019-09-24 A | 2019-09-27 | 14, 4, 13 | 10% | 3.6d | 2019-09-24 | 2019-09-27 | 4d | 0.4d | 0d |  | Ed [50%]; Eric [50%] | 32h | 3.2h |
| 16 | 2.4 | Integrate and test in SN002 | 3d | 2019-09-30 | 2019-10-02 | 15, 4 |  |  | 2019-09-30 | 2019-10-02 | 3d | 12d | 0d |  | Ed [50%]; Eric [50%] | 24h |  |
| 17 | 2.5 | Integrate and test in SN001 | 2.67d? | 2019-10-21 | 2019-10-23 | 2, 16 |  |  | 2019-10-21 | 2019-10-23 | 2.67d? | 0d |  |  | Ed [50%]; Eric [50%]; Gene | 32h |  |
| 19 | 3 | **Finish ISB CCA** | 30d? | 2019-08-20 A | 2019-09-30 |  | 40% | 18d? | 2019-08-20 | 2019-09-30 | 30d? | 16.67d |  |  |  | 80h | 22.4h |
| 20 | 3.1 | Chad's bench testing | 4d | 2019-08-20 A | 2019-08-23 |  | 80% | 0.8d | 2019-08-20 | 2019-08-23 | 4d | 2.4d | 0d |  | Chad [50%] | 16h | 12.8h |
| 21 | 3.2 | Eric's software testing | 4d? | 2019-08-26 A | 2019-08-29 | 20 | 60% | 1.6d? | 2019-08-26 | 2019-08-29 | 4d? | 32.67d | 16d |  | Eric [50%] | 16h | 9.6h |
| 22 | 3.3 | Integrate and test in SN003 | 2d | 2019-09-23 | 2019-09-24 | 21, 20, 5 |  |  | 2019-09-23 | 2019-09-24 | 2d | 16.67d | 0d |  | Chad [50%]; Eric [50%] | 16h |  |
| 23 | 3.4 | Integrate and test in SN002 | 2d? | 2019-09-25 | 2019-09-26 | 22, 5 |  |  | 2019-09-25 | 2019-09-26 | 2d? | 16.67d | 0d |  | Chad [50%]; Eric [50%] | 16h |  |
| 24 | 3.5 | Integrate and test in SN001 | 2d? | 2019-09-27 | 2019-09-30 | 3, 23 |  |  | 2019-09-27 | 2019-09-30 | 2d? | 16.67d | 0d |  | Chad [50%]; Eric [50%] | 16h |  |
| 26 | 4 | **Finish BT CCA** | 34d? | 2019-08-20 A | 2019-10-04 |  | 42% | 19.83d? | 2019-08-20 | 2019-10-04 | 34d? | 35.67d |  |  |  | 64h | 8h |
| 27 | 4.1 | Finish Design | 1d | 2019-08-20 A | 2019-08-20 A |  | 100% |  | 2019-08-20 | 2019-08-20 | 1d |  |  |  | Chad | 8h | 8h |
| 28 | 4.2 | Layout | 9d | 2019-09-05 A | 2019-09-17 A | 27 | 100% |  | 2019-09-05 | 2019-09-17 | 9d |  |  | finish no earlier than 2019-09-17 |  |  |  |
| 29 | 4.3 | Build CCA | 5d | 2019-09-18 | 2019-09-24 | 28 |  |  | 2019-09-18 | 2019-09-24 | 5d | 35.67d | 0d |  |  |  |  |
| 30 | 4.4 | Chad's bench testing | 2d | 2019-09-25 | 2019-09-26 | 29 |  |  | 2019-09-25 | 2019-09-26 | 2d | 35.67d | 0d |  | Chad [50%] | 8h |  |
| 31 | 4.5 | Eric's software testing | 2d | 2019-09-27 | 2019-09-30 | 30 |  |  | 2019-09-27 | 2019-09-30 | 2d | 35.67d | 0d |  | Eric [50%] | 8h |  |
| 32 | 4.6 | Wire Harness Drawing | 1d? | 2019-08-20 | 2019-08-20 |  |  |  | 2019-08-20 | 2019-08-20 | 1d? | 68.67d |  |  | Chad | 8h |  |
| 33 | 4.7 | Integrate and test in SN003 | 2d | 2019-10-01 | 2019-10-02 | 31 |  |  | 2019-10-01 | 2019-10-02 | 2d | 35.67d | 0d |  | Chad [50%]; Eric [50%] | 16h |  |
| 34 | 4.8 | Integrate and test in SN002 | 1d? | 2019-10-03 | 2019-10-03 | 33 |  |  | 2019-10-03 | 2019-10-03 | 1d? | 35.67d | 0d |  | Chad [50%]; Eric [50%] | 8h |  |
| 35 | 4.9 | Integrate and test in SN001 | 1d? | 2019-10-04 | 2019-10-04 | 34 |  |  | 2019-10-04 | 2019-10-04 | 1d? | 35.67d |  |  | Chad [50%]; Eric [50%] | 8h |  |
| 37 | 5 | Finish shore side Iridium testing | 6d? | 2019-08-20 | 2019-08-27 |  |  |  | 2019-08-20 | 2019-08-27 | 6d? | 63.67d |  |  | Eric [50%] | 24h |  |
| 39 | 6 | Finish Building SN003 | 2d? | 2019-09-30 | 2019-10-01 | 22, 15 |  |  | 2019-09-30 | 2019-10-01 | 2d? | 23.67d | 0d |  | Paul | 16h |  |
| 40 | 7 | Finish Building SN002 | 2d? | 2019-10-03 | 2019-10-04 | 23, 16 |  |  | 2019-10-03 | 2019-10-04 | 2d? | 24.67d | 0d |  | Paul | 16h |  |

Notes:
- 4: +2 days for unit 1, 5 days for next 2 sets
- 5: 2 days for unit 1, 5 days for next 2 sets
- 6: Jose to provide real date
- 7: Jose to decide build in or out and provide a date
- 8: Need to find extra boards
- 9: next Monday
- 15: 2 days after harnesses
- 16: reevalute integrating in series or parallel
- 20: 1 and 2 done
- 21: 1 and 2 done
- 22: Chad to check on harnesses

| ID | WBS | Task | Type | Duration | Start | Finish | Predecessors | Baseline start | Baseline finish | Baseline duration | Total slack | Free slack | Resources | Work |
| --- | --- | --- | --- | --- | --- | --- | --- | --- | --- | --- | --- | --- | --- | --- |
| 42 | 8 | **Bench Test SN003** |  | 1d? | 2019-10-02 | 2019-10-02 | 22, 15, 39 | 2019-10-02 | 2019-10-04 | 3d | 23.67d | 0d | Gene; Eric | 16h |
| 43 | 8.1 | Install BT module |  | 1d? | 2019-10-02 | 2019-10-02 |  |  |  |  | 23.67d |  |  |  |
| 44 | 8.2 | BT module Wire Harness |  | 1d? | 2019-10-02 | 2019-10-02 |  |  |  |  | 23.67d |  |  |  |
| 45 | 8.3 | Confirm new BT module and make this the base line design |  | 1d? | 2019-10-02 | 2019-10-02 |  |  |  |  | 23.67d |  |  |  |
| 46 | 8.4 | Complete BT module configuration process |  | 1d? | 2019-10-02 | 2019-10-02 |  |  |  |  | 23.67d |  |  |  |
| 47 | 8.5 | Finish mods to BT modules |  | 1d? | 2019-10-02 | 2019-10-02 |  |  |  |  | 23.67d |  |  |  |
| 48 | 8.6 | Finalize 1) LHE, 2) schematic and 3) wire harnesses |  | 1d? | 2019-10-02 | 2019-10-02 |  |  |  |  | 23.67d |  |  |  |
| 49 | 8.7 | Eric's SW tasks |  | 1d? | 2019-10-02 | 2019-10-02 |  |  |  |  | 23.67d |  |  |  |
| 50 | 8.8 | Finalize battery pack |  | 1d? | 2019-10-02 | 2019-10-02 |  |  |  |  | 23.67d |  |  |  |
| 51 | 8.9 | Finish MSC Wiring |  | 1d? | 2019-10-02 | 2019-10-02 |  |  |  |  | 23.67d |  |  |  |
| 52 | 8.10 | BT and Iridium Deck Test |  | 1d? | 2019-10-02 | 2019-10-02 |  |  |  |  | 23.67d |  |  |  |
| 53 | 8.11 | Finalize ready for oil fill test procedure |  | 1d? | 2019-10-02 | 2019-10-02 |  |  |  |  | 23.67d |  |  |  |
| 54 | 8.12 | Tear down for 2nd WH build |  | 1d? | 2019-10-02 | 2019-10-02 |  |  |  |  | 23.67d |  |  |  |
| 55 | 8.13 | Rebuild after WH teardown |  | 1d? | 2019-10-02 | 2019-10-02 |  |  |  |  | 23.67d |  |  |  |
| 56 | 8.14 | Fill with oil |  | 1d? | 2019-10-02 | 2019-10-02 |  |  |  |  | 23.67d |  |  |  |
| 57 | 8.15 | Final BE full pressure test |  | 1d? | 2019-10-02 | 2019-10-02 |  |  |  |  | 23.67d |  |  |  |
| 58 | 9 | Tank Test SN003 |  | 2d | 2019-10-10 | 2019-10-11 | 60 | 2019-10-10 | 2019-10-11 | 2d | 24.67d |  | Gene | 16h |
| 59 | 10 | Bench test SN001 |  | 3d? | 2019-10-23 | 2019-10-28 | 17, 24 | 2019-10-23 | 2019-10-28 | 3d? | 0d |  | Gene; Eric | 48h |
| 60 | 11 | Bench Test SN002 |  | 3d? | 2019-10-07 | 2019-10-09 | 16, 23, 40 | 2019-10-07 | 2019-10-09 | 3d? | 24.67d | 0d | Gene; Eric | 48h |
| 62 | 12 | Tank Test SN001 |  | 2d | 2019-10-28 | 2019-10-30 | 59 | 2019-10-28 | 2019-10-30 | 2d | 0d |  | Gene | 16h |
| 63 | 13 | Tank Test SN002 |  | 2d | 2019-10-03 | 2019-10-04 | 42 | 2019-10-07 | 2019-10-08 | 2d | 23.67d |  | Gene | 16h |
| 65 | 14 | Sea Test SN001 |  | 6d | 2019-10-30 | 2019-11-07 | 62 | 2019-10-30 | 2019-11-07 | 6d | 0d |  | Gene [50%] | 24h |
| 66 | 15 | Sea Test SN002 |  | 6d | 2019-11-07 | 2019-11-15 | 63, 65 | 2019-11-07 | 2019-11-15 | 6d | 0d |  | Gene [50%] | 24h |
| 67 | 16 | Sea Test SN003 |  | 6d | 2019-11-15 | 2019-11-25 | 66, 58 | 2019-11-15 | 2019-11-25 | 6d | 0d |  | Gene [50%] | 24h |
| 69 | 17 | Finish Operational Software |  | 20d? | 2019-08-20 | 2019-09-16 |  | 2019-08-20 | 2019-09-16 | 20d? | 49.67d |  | Gene Eric | 160h |
| 71 | 18 | Pre-run Science mission | milestone | 0d | 2019-11-25 | 2019-11-25 | 67, 65, 66 | 2019-11-25 | 2019-11-25 |  | 0d |  | Gene; Eric |  |

Notes:
- 43: Gene
- 44: Jose
- 45: Eric
- 46: Eric
- 47: Eric
- 48: Ed
- 49: Eric
- 50: Gene
- 51: Eric
- 52: Eric and Gene
- 53: Gene and Eric
- 54: Jose
- 55: Jose
- 56: Gene
- 57: Gene and Eric
